# Implementation-Plan-Schedule-revised

Schedule from MS Project, 2014-05-01 to 2015-09-28.
Microsoft

## Calendars

- Standard: Mon-Fri 08:00-12:00, 13:00-17:00; Sat-Sun off.

## Schedule

| ID | WBS | Task | Type | Duration | Start | Finish | Predecessors | Total slack |
| --- | --- | --- | --- | --- | --- | --- | --- | --- |
| 1 | 1 | **DETAIL DESIGN** |  | 173d | 2014-05-01 | 2014-12-29 |  | 0d |
| 2 | 1.1 | **Phase I** |  | 37d | 2014-05-01 | 2014-06-22 |  | 0d |
| 3 | 1.1.1 | Start of Phase I detail design | milestone, manual | 0d | 2014-05-01 | 2014-05-01 |  |  |
| 4 | 1.1.2 | Axial Correction Supplements | manual | 16d | 2014-05-01 | 2014-05-22 | 3 |  |
| 5 | 1.1.3 | Procedure for shutter sealing reparation | manual | 12d | 2014-06-06 | 2014-06-22 |  |  |
| 6 | 1.1.4 | Procedure for cleaning and reparation of dome structure cracks and defects | manual | 38d | 2014-05-01 | 2014-06-22 |  |  |
| 7 | 1.2 | **Phase II** |  | 86d | 2014-09-01 | 2014-12-29 |  | 0d |
| 8 | 1.2.1 | Start of Phase II detail design | milestone, manual | 0d | 2014-09-01 | 2014-09-01 |  |  |
| 9 | 1.2.2 | Systems Engineering | manual | 86d | 2014-09-01 | 2014-12-29 |  |  |
| 10 | 1.2.3 | Bogies and Hydraulic System | manual | 86d | 2014-09-01 | 2014-12-29 |  |  |
| 11 | 1.2.4 | Take-Up System | manual | 64d | 2014-10-01 | 2014-12-29 |  |  |
| 12 | 1.2.5 | Counterweight System (optional) | manual | 86d | 2014-09-01 | 2014-12-29 |  |  |
| 13 | 1.2.6 | Windscreen Actions | manual | 64d | 2014-10-01 | 2014-12-29 |  |  |
| 14 | 1.2.7 | Shutters Drive System | manual | 45d | 2014-09-01 | 2014-10-31 |  |  |
| 15 | 2 | **MANUFACTURING AND PROCUREMENT** |  | 245d | 2014-05-23 | 2015-04-30 |  | 0d |
| 16 | 2.1 | **Phase I** |  | 28d | 2014-05-23 | 2014-07-01 |  | 0d |
| 17 | 2.1.1 | Start of Phase I manufact/procurement | milestone, manual | 0d | 2014-05-23 | 2014-05-23 |  |  |
| 18 | 2.1.2 | Axial Correction Supplements | manual | 28d | 2014-05-23 | 2014-07-01 | 4 |  |
| 19 | 2.2 | **Phase II** |  | 129d | 2014-11-03 | 2015-04-30 |  | 0d |
| 20 | 2.2.1 | Purchase Order for roller chains, motors and gearboxes | milestone, manual | 0d | 2014-11-03 | 2014-11-03 |  |  |
| 21 | 2.2.2 | Start of Phase II rest of systems manufacturing | milestone, manual | 0d | 2014-12-30 | 2014-12-30 |  |  |
| 22 | 2.2.3 | Bogies and Hydraulic System | manual | 88d | 2014-12-30 | 2015-04-30 | 10 |  |
| 23 | 2.2.4 | Take-Up System | manual | 88d | 2014-12-30 | 2015-04-30 | 11 |  |
| 24 | 2.2.5 | Counterweight System (optional) | manual | 88d | 2014-12-30 | 2015-04-30 | 12 |  |
| 25 | 2.2.6 | Windscreen Actions | manual | 88d | 2014-12-30 | 2015-04-30 | 13 |  |
| 26 | 2.2.7 | Shutters Drive System | manual | 126d | 2014-11-06 | 2015-04-30 | 14, 20 |  |

| ID | WBS | Task | Type | Duration | Start | Finish | Predecessors | Total slack |
| --- | --- | --- | --- | --- | --- | --- | --- | --- |
| 27 | 3 | **ON-SITE ASSEMBLY AND COMMISSIONING** |  | 330d | 2014-06-23 | 2015-09-28 |  | 0d |
| 28 | 3.1 | **Phase I** |  | 24d | 2014-06-23 | 2014-07-24 |  | 0d |
| 29 | 3.1.1 | Start of Phase I on-site installation | milestone, manual | 0d | 2014-06-23 | 2014-06-23 |  |  |
| 30 | 3.1.2 | Axial Correction Supplements | manual | 6d | 2014-07-04 | 2014-07-11 | 18, 31 |  |
| 31 | 3.1.3 | Shutter sealing reparation | manual | 5d | 2014-06-23 | 2014-06-27 |  |  |
| 32 | 3.1.4 | Cleaning and reparation of dome structure cracks and defects | manual | 9d | 2014-07-14 | 2014-07-24 | 30 |  |
| 33 | 3.2 | **Phase II** |  | 106d | 2015-05-01 | 2015-09-25 |  | 0d |
| 34 | 3.2.1 | Start of Phase II on-site installation | milestone, manual | 0d | 2015-05-01 | 2015-05-01 |  |  |
| 35 | 3.2.2 | Bogies and Hydraulic System | manual | 36d | 2015-05-01 | 2015-06-19 | 22 |  |
| 36 | 3.2.3 | Take-Up System | manual | 5d | 2015-07-13 | 2015-07-17 | 23, 39 |  |
| 37 | 3.2.4 | Counterweight System (optional) | manual | 31d | 2015-07-06 | 2015-08-17 | 24, 35 |  |
| 38 | 3.2.5 | Windscreen Actions | manual | 24d | 2015-07-27 | 2015-08-27 | 25, 39, 35 |  |
| 39 | 3.2.6 | Upper Shutter Drive System | manual | 15d | 2015-06-22 | 2015-07-10 | 26, 35 |  |
| 40 | 3.2.7 | Lower Shutter Drive System | manual | 15d | 2015-07-20 | 2015-08-07 | 36 |  |
| 41 | 3.2.8 | Start of SAT | milestone, manual | 0d | 2015-08-31 | 2015-08-31 |  |  |
| 42 | 3.2.9 | SAT and Commissioning | manual | 20d | 2015-08-31 | 2015-09-25 | 35, 36, 37, 38, 39, 41, 40 |  |
| 43 | 3.3 | END | milestone, manual | 0d | 2015-09-28 | 2015-09-28 | 42 |  |
